Schedule from MS Project, 2024-11-06 to 2025-06-07, status date 2022-11-14.

## Calendars

- Standard: Mon-Thu 08:00-12:00, 13:00-17:00; Fri off; Sat-Sun 08:00-12:00, 13:00-17:00.

## Schedule

| ID | WBS | Task | Type | Duration | Start | Finish | Predecessors | Total slack | Free slack |
| --- | --- | --- | --- | --- | --- | --- | --- | --- | --- |
| 1 | 1 | **Purchase of gas bank pressure boosting station storage tanks** |  | 183d | 2024-11-06 | 2025-06-07 |  | 0d |  |
| 2 | 1.1 | Advanced Payment Date | milestone | 0d | 2024-11-06 | 2024-11-06 |  | 15d |  |
| 3 | 1.2 | Effective Date | milestone | 0d | 2024-11-06 | 2024-11-06 |  | 0d |  |
| 4 | 1.3 | PIM |  | 1d | 2024-11-06 | 2024-11-06 |  | 182d |  |
| 5 | 1.4 | **Documentation** |  | 42d | 2024-11-06 | 2024-12-24 |  | 0d |  |
| 6 | 1.4.1 | **Documentation according to VPIS** |  | 42d | 2024-11-06 | 2024-12-24 | 3 | 0d |  |
| 7 | 1.4.1.1 | **General/ Management** |  | 30d | 2024-11-06 | 2024-12-10 |  | 141d |  |
| 8 | 1.4.1.1.1 | VENDOR PRINT INDEX & SCHEDULE (VPIS) |  | 10d | 2024-11-06 | 2024-11-17 | 3 | 141d | 0d |
| 9 | 1.4.1.1.2 | WORK BEAKDOWN STRUCTURE |  | 10d | 2024-11-10 | 2024-11-20 | 8SS+3d | 168d | 0d |
| 10 | 1.4.1.1.3 | TIME SCHEDULE |  | 10d | 2024-11-12 | 2024-11-23 | 9SS+2d | 168d |  |
| 11 | 1.4.1.1.4 | FINAL VENDOR DATA BOOK INDEX |  | 10d | 2024-11-24 | 2024-12-04 | 15FS+5d | 158d |  |
| 12 | 1.4.1.1.5 | SUB VENDOR LIST |  | 10d | 2024-11-18 | 2024-11-28 | 25 | 153d | 0d |
| 13 | 1.4.1.1.6 | SPARE PART LIST |  | 10d | 2024-11-30 | 2024-12-10 | 12 | 153d |  |
| 14 | 1.4.1.2 | **Procedure/Plan** |  | 42d | 2024-11-06 | 2024-12-24 |  | 141d |  |
| 15 | 1.4.1.2.1 | INSPECTION & TEST PLAN (ITP) |  | 10d | 2024-11-06 | 2024-11-17 | 8SS | 141d | 0d |
| 16 | 1.4.1.2.2 | FABRICATION PROCEDURE |  | 10d | 2024-11-09 | 2024-11-19 | 15SS+2d | 141d | 0d |
| 17 | 1.4.1.2.3 | WPS & PQR |  | 10d | 2024-11-11 | 2024-11-21 | 16SS+2d | 141d | 0d |
| 18 | 1.4.1.2.4 | NDT PROCEDURE |  | 10d | 2024-11-14 | 2024-11-25 | 17SS+3d | 141d | 0d |
| 19 | 1.4.1.2.5 | WELDING REPAIR PROCEDURE |  | 10d | 2024-11-18 | 2024-11-28 | 18SS+3d | 141d | 0d |
| 20 | 1.4.1.2.6 | VACUUM & OIL LEAK TEST PROCEDURE |  | 10d | 2024-11-30 | 2024-12-10 | 19 | 141d | 0d |
| 21 | 1.4.1.2.7 | HYDROSTATIC TEST PROCEDURE |  | 10d | 2024-12-02 | 2024-12-12 | 20SS+2d | 141d | 0d |
| 22 | 1.4.1.2.8 | BLASTING, PAINTING AND LINING PROCEDURE |  | 10d | 2024-12-14 | 2024-12-24 | 21 | 141d |  |
| 23 | 1.4.1.3 | **Elevated Potable Water Tank (TK-2209)** |  | 25d | 2024-11-06 | 2024-12-04 |  | 0d |  |
| 24 | 1.4.1.3.1 | **Calculation** |  | 10d | 2024-11-06 | 2024-11-17 |  | 0d |  |
| 25 | 1.4.1.3.1.1 | MECHANICAL CALCULATION BOOK FOR ELEVATED POTABLE WATER TANK (TK-2209) |  | 10d | 2024-11-06 | 2024-11-17 | 3 | 0d |  |

| ID | WBS | Task | Duration | Start | Finish | Predecessors | Total slack | Free slack |
| --- | --- | --- | --- | --- | --- | --- | --- | --- |
| 26 | 1.4.1.3.2 | **Drawing** | 20d | 2024-11-12 | 2024-12-04 |  | 0d |  |
| 27 | 1.4.1.3.2.1 | GENERAL ARRANGEMENT FOR ELEVATED POTABLE WATER TANK (TK-2209) | 10d | 2024-11-12 | 2024-11-23 | 25SS+5d | 0d |  |
| 28 | 1.4.1.3.2.2 | DETAIL DRAWING FOR ELEVATED POTABLE WATER TANK (TK-2209) | 10d | 2024-11-12 | 2024-11-23 | 27SS | 0d |  |
| 29 | 1.4.1.3.2.3 | NAME PLATE DETAIL DRAWING FOR ELEVATED POTABLE WATER TANK (TK-2209) | 10d | 2024-11-24 | 2024-12-04 | 28 | 158d |  |
| 30 | 1.4.1.4 | **Lean Glycol Storage Tank (TK-2102)** | 30d | 2024-11-09 | 2024-12-12 |  | 151d |  |
| 31 | 1.4.1.4.1 | **Calculation** | 10d | 2024-11-09 | 2024-11-19 |  | 151d |  |
| 32 | 1.4.1.4.1.1 | MECHANICAL CALCULATION BOOK FOR LEAN GLYCOL STORAGE TANK (TK-2102) | 10d | 2024-11-09 | 2024-11-19 | 25SS+2d | 151d | 0d |
| 33 | 1.4.1.4.2 | **Drawing** | 20d | 2024-11-20 | 2024-12-12 |  | 151d |  |
| 34 | 1.4.1.4.2.1 | GENERAL ARRANGEMENT FOR FLEAN GLYCOL STORAGE TANK (TK-2102) | 10d | 2024-11-20 | 2024-12-01 | 32 | 151d | 0d |
| 35 | 1.4.1.4.2.2 | DETAIL DRAWING FOR LEAN GLYCOL STORAGE TANK (TK-2102) | 10d | 2024-11-20 | 2024-12-01 | 34SS | 151d | 0d |
| 36 | 1.4.1.4.2.3 | NAME PLATE DETAIL DRAWING FOR LEAN GLYCOL STORAGE TANK (TK-2102) | 10d | 2024-12-02 | 2024-12-12 | 35 | 151d |  |
| 37 | 1.4.1.5 | **Fire Water Tanks (TK-2301 A/B)** | 24d | 2024-11-06 | 2024-12-03 |  | 159d |  |
| 38 | 1.4.1.5.1 | **Calculation** | 10d | 2024-11-11 | 2024-11-21 |  | 159d |  |
| 39 | 1.4.1.5.1.1 | MECHANICAL CALCULATION BOOK FOR FIRE WATER TANKS (TK-2301 A/B) | 10d | 2024-11-11 | 2024-11-21 | 32SS+2d | 159d | 0d |
| 40 | 1.4.1.5.1.2 | ROOF STRUCTURE CALCULATION FOR FIRE WATER TANKS (TK-2301 A/B) | 10d | 2024-11-11 | 2024-11-21 | 39SS | 169d |  |
| 41 | 1.4.1.5.2 | **Drawing** | 24d | 2024-11-06 | 2024-12-03 |  | 159d |  |
| 42 | 1.4.1.5.2.1 | GENERAL ARRANGEMENT FOR FIRE WATER TANKS (TK-2301 A/B) | 10d | 2024-11-23 | 2024-12-03 | 39 | 159d | 0d |
| 43 | 1.4.1.5.2.2 | DETAIL DRAWINGS FOR FIRE WATER TANKS (TK-2301 A/B) | 10d | 2024-11-23 | 2024-12-03 | 42SS | 159d |  |
| 44 | 1.4.1.5.2.3 | NAME PLATE DETAIL DRAWING FOR FIRE WATER TANKS (TK-2301 A/B) | 10d | 2024-11-06 | 2024-11-17 |  | 173d |  |
| 45 | 1.5 | **Test and Inspection Activities** | 164d | 2024-11-24 | 2025-06-02 |  | 0d |  |
| 46 | 1.5.1 | **Storage Tank (TK-2102(Glycol Storage Tank), TK-2301A, TK-2301B (Fire Water Tank))** | 164d | 2024-11-24 | 2025-06-02 |  | 0d |  |
| 47 | 1.5.1.1 | **Material Inspection** | 19d | 2024-11-24 | 2024-12-15 |  | 0d |  |
| 48 | 1.5.1.1.1 | Raw Material Inspection | 15d | 2024-11-24 | 2024-12-10 | 2, 27, 28 | 0d |  |
| 49 | 1.5.1.1.2 | Welding Consumable | 9d | 2024-12-05 | 2024-12-15 | 48SS+10d, 2 | 17d |  |

| ID | WBS | Task | Duration | Start | Finish | Predecessors | Total slack |
| --- | --- | --- | --- | --- | --- | --- | --- |
| 50 | 1.5.1.2 | **Inspection of Shop Fabrication** | 54d | 2024-12-11 | 2025-02-11 |  | 0d |
| 51 | 1.5.1.2.1 | Marking, Cutting, Edge Preparation | 15d | 2024-12-11 | 2024-12-28 | 48 | 0d |
| 52 | 1.5.1.2.2 | Welding | 24d | 2025-01-05 | 2025-02-01 | 54, 49 | 0d |
| 53 | 1.5.1.2.3 | NDT Tests (MT, PT, RT, UT) | 9d | 2025-02-02 | 2025-02-11 | 52 | 0d |
| 54 | 1.5.1.2.4 | Rolling, Saddle & Support Settlement | 6d | 2024-12-29 | 2025-01-04 | 51 | 0d |
| 55 | 1.5.1.3 | **Loading & Shipping from Shop to Site** | 4d | 2025-02-12 | 2025-02-16 |  | 0d |
| 56 | 1.5.1.3.1 | Packing & shipping Inspection | 4d | 2025-02-12 | 2025-02-16 | 50 | 0d |
| 57 | 1.5.1.4 | **Erection** | 59d | 2025-02-17 | 2025-04-26 |  | 0d |
| 58 | 1.5.1.4.1 | Fit Up((Annular, Shell, Roof) ) | 10d | 2025-02-17 | 2025-02-27 | 56 | 0d |
| 59 | 1.5.1.4.2 | Sand Blast for Bottom Plate | 4d | 2025-03-01 | 2025-03-04 | 58 | 0d |
| 60 | 1.5.1.4.3 | Marking & Cutting of Nozzles / Manholes Locations | 5d | 2025-03-01 | 2025-03-05 | 59SS | 0d |
| 61 | 1.5.1.4.4 | Fit Up Nozzles / Manholes to Shell &Roof | 5d | 2025-03-06 | 2025-03-11 | 60 | 0d |
| 62 | 1.5.1.4.5 | Fit Up Roof Structure | 7d | 2025-03-12 | 2025-03-19 | 61 | 0d |
| 63 | 1.5.1.4.6 | Fit Up External / Internal Attachments | 2d | 2025-03-20 | 2025-03-22 | 62 | 0d |
| 64 | 1.5.1.4.7 | Welding | 14d | 2025-03-23 | 2025-04-07 | 63 | 0d |
| 65 | 1.5.1.4.8 | Final Inspection | 4d | 2025-04-08 | 2025-04-12 | 64 | 0d |
| 66 | 1.5.1.4.9 | NDT (RT, PT, MT, UT, VT) | 4d | 2025-04-13 | 2025-04-16 | 65 | 0d |
| 67 | 1.5.1.4.10 | Oil Leak Test | 4d | 2025-04-17 | 2025-04-21 | 66 | 0d |
| 68 | 1.5.1.4.11 | Vacuum & Pad Test | 4d | 2025-04-22 | 2025-04-26 | 67 | 0d |
| 69 | 1.5.1.5 | **Hydrostatic Test** | 5d | 2025-04-27 | 2025-05-01 |  | 0d |
| 70 | 1.5.1.5.1 | Calibration certificate | 1d | 2025-04-27 | 2025-04-27 | 57 | 0d |
| 71 | 1.5.1.5.2 | Hydrostatic test | 4d | 2025-04-28 | 2025-05-01 | 70, 68 | 0d |
| 72 | 1.5.1.6 | **Surface Preparation & painting inspection** | 26d | 2025-05-03 | 2025-06-01 |  | 0d |
| 73 | 1.5.1.6.1 | Paint Material Insp. | 5d | 2025-05-03 | 2025-05-07 | 71 | 0d |
| 74 | 1.5.1.6.2 | Surface Preparation | 9d | 2025-05-08 | 2025-05-18 | 73 | 0d |
| 75 | 1.5.1.6.3 | Painting Inspection | 7d | 2025-05-19 | 2025-05-26 | 74 | 0d |
| 76 | 1.5.1.6.4 | Final Inspection | 5d | 2025-05-27 | 2025-06-01 | 75 | 0d |

| ID | WBS | Task | Duration | Start | Finish | Predecessors | Total slack | Free slack |
| --- | --- | --- | --- | --- | --- | --- | --- | --- |
| 77 | 1.5.1.7 | **Name plate** | 1d | 2025-06-02 | 2025-06-02 |  | 0d |  |
| 78 | 1.5.1.7.1 | Name Plate | 1d | 2025-06-02 | 2025-06-02 | 76 | 0d |  |
| 79 | 1.5.2 | **Potable Tank (TK-2209)** | 127d | 2025-01-04 | 2025-05-31 |  | 2d |  |
| 80 | 1.5.2.1 | **Material Inspection** | 10d | 2025-01-04 | 2025-01-14 |  | 2d |  |
| 81 | 1.5.2.1.1 | Raw Material Inspection | 10d | 2025-01-04 | 2025-01-14 | 48FS+20d | 2d | 0d |
| 82 | 1.5.2.1.2 | Welding Consumable | 2d | 2025-01-04 | 2025-01-05 | 81SS | 59d | 57d |
| 83 | 1.5.2.2 | **Inspection During Fabrication** | 78d | 2025-01-15 | 2025-04-15 |  | 2d |  |
| 84 | 1.5.2.2.1 | Marking, Cutting, Edge Preparation | 10d | 2025-01-15 | 2025-01-26 | 81 | 2d | 0d |
| 85 | 1.5.2.2.2 | Rolling | 10d | 2025-01-27 | 2025-02-06 | 84 | 2d | 0d |
| 86 | 1.5.2.2.3 | Structure part Fabrication | 15d | 2025-02-08 | 2025-02-24 | 85 | 2d | 0d |
| 87 | 1.5.2.2.4 | Fit up | 14d | 2025-02-25 | 2025-03-12 | 86 | 2d | 0d |
| 88 | 1.5.2.2.5 | Welding | 19d | 2025-03-13 | 2025-04-03 | 87, 82 | 2d | 0d |
| 89 | 1.5.2.2.6 | NDT after welding | 10d | 2025-04-05 | 2025-04-15 | 88 | 2d | 0d |
| 90 | 1.5.2.3 | **Final Visual & Dimensional** | 2d | 2025-04-16 | 2025-04-17 |  | 2d |  |
| 91 | 1.5.2.3.1 | Final Visual and Dimensional Inspection | 2d | 2025-04-16 | 2025-04-17 | 89 | 2d | 0d |
| 92 | 1.5.2.4 | **Hydrostatic Test** | 11d | 2025-04-19 | 2025-04-30 |  | 2d |  |
| 93 | 1.5.2.4.1 | Calibration certificate | 4d | 2025-04-19 | 2025-04-22 | 91 | 2d | 0d |
| 94 | 1.5.2.4.2 | Hydrostatic test | 5d | 2025-04-23 | 2025-04-28 | 93 | 2d | 0d |
| 95 | 1.5.2.4.3 | Draining & Drying | 2d | 2025-04-29 | 2025-04-30 | 94 | 2d | 0d |
| 96 | 1.5.2.5 | **Surface Preparation & painting inspection** | 24d | 2025-05-01 | 2025-05-28 |  | 2d | 1d |
| 97 | 1.5.2.5.1 | Paint Material Insp. | 6d | 2025-05-01 | 2025-05-07 | 95 | 2d | 0d |
| 98 | 1.5.2.5.2 | Surface Preparation | 6d | 2025-05-08 | 2025-05-14 | 97 | 2d | 0d |
| 99 | 1.5.2.5.3 | Painting Inspection | 6d | 2025-05-15 | 2025-05-21 | 98 | 2d | 0d |
| 100 | 1.5.2.5.4 | Final Inspection | 6d | 2025-05-22 | 2025-05-28 | 99 | 2d | 0d |

| ID | WBS | Task | Duration | Start | Finish | Predecessors | Total slack | Free slack |
| --- | --- | --- | --- | --- | --- | --- | --- | --- |
| 101 | 1.5.2.6 | **Name plate** | 2d | 2025-05-29 | 2025-05-31 |  | 2d |  |
| 102 | 1.5.2.6.1 | Name Plate Check | 1d | 2025-05-29 | 2025-05-29 | 100 | 2d | 0d |
| 103 | 1.5.2.6.2 | Packing & Shipping Inspection | 1d | 2025-05-31 | 2025-05-31 | 102, 96 | 2d |  |
| 104 | 1.6 | **INSPECTION RELEASE NOTE** | 2d | 2025-06-03 | 2025-06-04 |  | 0d |  |
| 105 | 1.6.1 | Release Note | 2d | 2025-06-03 | 2025-06-04 | 46, 79, 103SS | 0d |  |
| 106 | 1.7 | **INSPECTION CERTIFICATE** | 4d | 2025-06-03 | 2025-06-07 |  | 0d |  |
| 107 | 1.7.1 | Inspection Certificate | 4d | 2025-06-03 | 2025-06-07 | 79, 46 | 0d |  |
| 108 | 1.8 | **FINAL DATA BOOK** | 2d | 2025-06-05 | 2025-06-07 |  | 0d |  |
| 109 | 1.8.1 | Final Document Preparation | 2d | 2025-06-05 | 2025-06-07 | 105 | 0d |  |
